# AB-04 - systeemwand+plafond

Schedule from MS Project, 2003-01-12 to 2003-02-05, status date 2003-01-08.
BAM Nelissen Van Egteren

## Calendars

- ALLEEN WERKDAGEN: Mon-Fri 08:30-12:30, 13:00-17:00; Sat-Sun off. Exceptions (off unless hours are given): 2003-01-11 to 2003-01-12 08:30-12:30, 13:00-17:00, 2003-01-18 to 2003-01-19 08:30-12:30, 13:00-17:00, 2003-01-25 to 2003-01-26 08:30-12:30, 13:00-17:00, 2003-02-01 to 2003-02-02 08:30-12:30, 13:00-17:00.

## Schedule

| ID | WBS | Task | Type | Duration | Start | Finish | Predecessors | Total slack |
| --- | --- | --- | --- | --- | --- | --- | --- | --- |
| 1 | 1 | **AFBOUWFASE** |  | 25d | 2003-01-12 | 2003-02-05 |  | 0d |
| 2 | 1.1 | **inbouwfase** |  | 13d | 2003-01-12 | 2003-01-24 |  | 0d |
| 3 | 1.1.1 | plafondleidingen vooraf | milestone | 0d | 2003-01-12 | 2003-01-12 |  | 25d |
| 4 | 1.1.2 | cementdekvloer aanbrengen |  | 5d | 2003-01-12 | 2003-01-16 |  | 0d |
| 5 | 1.1.3 | plafond regelwerk monteren |  | 5d | 2003-01-17 | 2003-01-21 | 4SS+5d | 0d |
| 6 | 1.1.4 | plafond armaturen+roosters |  | 5d | 2003-01-18 | 2003-01-22 | 5SS+1d | 0d |
| 7 | 1.1.5 | systeemwanden monteren |  | 5d | 2003-01-20 | 2003-01-24 | 6SS+2d | 0d |
| 8 | 1.2 | **afwerkingsfase** |  | 9d | 2003-01-22 | 2003-01-30 |  | 0d |
| 9 | 1.2.1 | plafondplaten inleggen |  | 5d | 2003-01-22 | 2003-01-26 | 7SS+2d | 0d |
| 10 | 1.2.2 | binnenwanden afwerken |  | 5d | 2003-01-24 | 2003-01-28 | 9SS+2d | 0d |
| 11 | 1.2.3 | vloerbedekking leggen |  | 5d | 2003-01-26 | 2003-01-30 | 10SS+2d | 0d |
| 12 | 1.3 | **uitrustingsfase** |  | 8d | 2003-01-28 | 2003-02-04 |  | 0d |
| 13 | 1.3.1 | binnendeurkozijnen+deuren |  | 5d | 2003-01-28 | 2003-02-01 | 11SS+2d | 0d |
| 14 | 1.3.2 | bouwkundige afmontage |  | 5d | 2003-01-29 | 2003-02-02 | 13SS+1d | 0d |
| 15 | 1.3.3 | electra afmontage |  | 5d | 2003-01-30 | 2003-02-03 | 14SS+1d | 0d |
| 16 | 1.3.4 | werktuigkundige afmontage |  | 5d | 2003-01-31 | 2003-02-04 | 15SS+1d | 0d |
| 17 | 1.4 | **opleveringsfase** |  | 4d | 2003-02-02 | 2003-02-05 |  | 0d |
| 18 | 1.4.1 | vooropnemen afbouw |  | 1d | 2003-02-02 | 2003-02-02 | 16SS+2d | 0d |
| 19 | 1.4.2 | herstelwerkzaamheden |  | 3d | 2003-02-03 | 2003-02-05 | 18SS+1d | 0d |
| 20 | 1.4.3 | opleveren bouwlaag | milestone | 0d | 2003-02-05 | 2003-02-05 | 19SS+3d | 0d |
